# Microsoft SharePoint Portal Server v2_0 Deployment

Schedule from MS Project, 2007-08-01 to 2008-01-28.

## Calendars

- Standard: Mon-Fri 08:00-12:00, 13:00-17:00; Sat-Sun off.

## Resources

| Resource |
| --- |
| Project Manager |
| MOSS 2007 Administrator |
| Desktop Administrator |
| Intranet/Internet Administrator |
| Workspace Coordinators |
| Database Administrator |
| Test/QA Lead |
| End Users |
| Education/Training Lead |

## Schedule

| ID | WBS | Task | Type | Duration | Start | Finish | Predecessors | Total slack | Resources | Work |
| --- | --- | --- | --- | --- | --- | --- | --- | --- | --- | --- |
| 1 | 1 | **Microsoft Office SharePoint Server 2007 Deployment** |  | 128.75d? | 2007-08-01 | 2008-01-28 |  | 0d |  | 6456h |
| 2 | 1.1 | **Envisioning** |  | 7.75d? | 2007-08-01 | 2007-08-10 |  | 0d |  | 96h |
| 3 | 1.1.1 | Evaluate Microsoft Office SharePoint Server 2007 features |  | 2d | 2007-08-01 | 2007-08-02 |  | 0d | MOSS 2007 Administrator; Intranet/Internet Administrator; End Users | 48h |
| 4 | 1.1.2 | Evaluate corporate objectives for Microsoft Office SharePoint Server 2007 (corporate knowledge sharing) |  | 2d | 2007-08-03 | 2007-08-06 | 3 | 0d | End Users | 16h |
| 5 | 1.1.3 | Evaluate customer needs for Microsoft Office SharePoint Server 2007 |  | 1d? | 2007-08-07 | 2007-08-07 | 4 | 0d | End Users | 8h |
| 6 | 1.1.4 | Formulate preliminary cost/benefit analysis |  | 4h | 2007-08-08 | 2007-08-08 | 5 | 0d |  | 4h |
| 7 | 1.1.5 | Determine project scope (lab, pilot, international/regional deployment, coexistence strategies, etc.) |  | 4h | 2007-08-08 | 2007-08-08 | 6 | 0d | Project Manager; End Users | 8h |
| 8 | 1.1.6 | Determine major milestones |  | 2h | 2007-08-09 | 2007-08-09 | 7 | 0d | Project Manager; End Users | 4h |
| 9 | 1.1.7 | Secure executive sponsorship and funding |  | 4h | 2007-08-09 | 2007-08-09 | 8 | 0d | Project Manager; End Users | 8h |
| 10 | 1.1.8 | Document as needed |  | 1d? | 2007-08-09 | 2007-08-10 | 9 | 0d |  |  |
| 11 | 1.1.9 | Envisioning complete | milestone | 0d | 2007-08-10 | 2007-08-10 | 10 | 0d |  |  |
| 12 | 1.2 | **Planning** |  | 42d? | 2007-08-10 | 2007-10-09 | 2 | 0d |  | 1824h |
| 13 | 1.2.1 | Define vision statement for requirements |  | 1d? | 2007-08-10 | 2007-08-13 |  | 120d |  |  |
| 14 | 1.2.2 | Determine success criteria |  | 1d? | 2007-08-10 | 2007-08-13 |  | 120d |  |  |
| 15 | 1.2.3 | **Assemble Project Teams, Define Roles** |  | 3d? | 2007-08-10 | 2007-08-15 |  | 0d |  | 104h |
| 16 | 1.2.3.1 | Assemble Project Teams |  | 1d? | 2007-08-10 | 2007-08-13 |  | 2d | Project Manager | 8h |
| 17 | 1.2.3.2 | Assign/define Development/Design team |  | 1d? | 2007-08-10 | 2007-08-13 |  | 2d | Project Manager | 8h |
| 18 | 1.2.3.3 | Assign/define Communication team |  | 1d? | 2007-08-10 | 2007-08-13 |  | 2d | Project Manager | 8h |
| 19 | 1.2.3.4 | Assign/define project manager |  | 1d | 2007-08-10 | 2007-08-13 | 11 | 0d | Project Manager | 8h |
| 20 | 1.2.3.5 | Assign/define infrastructure/network administrator |  | 1d | 2007-08-10 | 2007-08-13 | 11 | 0d | Project Manager | 8h |
| 21 | 1.2.3.6 | Assign/define deployment administrator |  | 1d | 2007-08-10 | 2007-08-13 | 11 | 0d | Project Manager | 8h |
| 22 | 1.2.3.7 | Assign/define desktop administrator |  | 1d | 2007-08-10 | 2007-08-13 | 11 | 0d | Project Manager | 8h |
| 23 | 1.2.3.8 | Assign/define intranet/Internet administrator |  | 1d | 2007-08-10 | 2007-08-13 | 11 | 0d | Project Manager | 8h |
| 24 | 1.2.3.9 | Assign/define workspace coordinators |  | 1d | 2007-08-10 | 2007-08-13 | 11 | 0d | Project Manager | 8h |
| 25 | 1.2.3.10 | Assign/define database administrator |  | 1d | 2007-08-10 | 2007-08-13 | 11 | 0d | Project Manager | 8h |
| 26 | 1.2.3.11 | Assign/define test/QA lead |  | 1d | 2007-08-10 | 2007-08-13 | 11 | 0d | Project Manager | 8h |
| 27 | 1.2.3.12 | Assign/define education/training lead |  | 1d | 2007-08-10 | 2007-08-13 | 11 | 0d | Project Manager | 8h |
| 28 | 1.2.3.13 | Establish subteam roles and responsibilities (infrastructure, security, hosting, etc.) |  | 1d | 2007-08-13 | 2007-08-14 | 19, 20, 21, 22, 23, 24, 25, 26, 27 | 0d | Project Manager | 8h |
| 29 | 1.2.3.14 | Document as needed |  | 1d? | 2007-08-14 | 2007-08-15 | 28 | 0d |  |  |
| 30 | 1.2.3.15 | Assemble project teams, define roles complete | milestone | 0d | 2007-08-15 | 2007-08-15 | 29 | 0d |  |  |

| ID | WBS | Task | Type | Duration | Start | Finish | Predecessors | Total slack | Free slack | Resources | Work |
| --- | --- | --- | --- | --- | --- | --- | --- | --- | --- | --- | --- |
| 31 | 1.2.4 | **Review/Detail Technical Requirements** |  | 5d? | 2007-08-10 | 2007-08-17 |  | 116d |  |  | 176h |
| 32 | 1.2.4.1 | Review/detail Microsoft Office SharePoint Server 2007 requirements |  | 1d | 2007-08-10 | 2007-08-13 |  | 116d | 0d | MOSS 2007 Administrator; Intranet/Internet Administrator | 16h |
| 33 | 1.2.4.2 | Content and Audit activities |  | 1d? | 2007-08-10 | 2007-08-13 |  | 120d |  | MOSS 2007 Administrator; Intranet/Internet Administrator | 16h |
| 34 | 1.2.4.3 | Review/detail technology architecture |  | 1d | 2007-08-10 | 2007-08-13 |  | 116d | 0d | MOSS 2007 Administrator; Intranet/Internet Administrator | 16h |
| 35 | 1.2.4.4 | Review/detail server hardware and software inventory |  | 1d | 2007-08-10 | 2007-08-13 |  | 116d | 0d | MOSS 2007 Administrator; Intranet/Internet Administrator | 16h |
| 36 | 1.2.4.5 | Review/detail client hardware and software inventory |  | 1d | 2007-08-10 | 2007-08-13 |  | 116d | 0d | Desktop Administrator | 8h |
| 37 | 1.2.4.6 | Review/detail current administrative/service delivery model |  | 1d | 2007-08-10 | 2007-08-13 |  | 116d | 0d | Desktop Administrator | 8h |
| 38 | 1.2.4.7 | Document current computing environment |  | 1d | 2007-08-13 | 2007-08-14 | 32, 34, 35, 36, 37 | 116d | 0d | MOSS 2007 Administrator; Desktop Administrator; Database Administrator | 24h |
| 39 | 1.2.4.8 | Document additional requirements |  | 1d? | 2007-08-14 | 2007-08-15 | 38 | 116d | 0d | MOSS 2007 Administrator; Desktop Administrator; Database Administrator | 24h |
| 40 | 1.2.4.9 | Determine need for client and server licenses |  | 1d? | 2007-08-15 | 2007-08-16 | 39 | 116d | 0d | MOSS 2007 Administrator; Desktop Administrator; Database Administrator | 24h |
| 41 | 1.2.4.10 | Document as needed |  | 1d? | 2007-08-16 | 2007-08-17 | 40 | 116d | 0d | MOSS 2007 Administrator; Desktop Administrator; Database Administrator | 24h |
| 42 | 1.2.4.11 | Review/detail current computing environment complete | milestone | 0d | 2007-08-17 | 2007-08-17 | 41 | 116d |  | MOSS 2007 Administrator; Desktop Administrator; Database Administrator |  |
| 43 | 1.2.5 | **Review/Detail Preliminary Enduser and Business Requirements** |  | 2d? | 2007-08-15 | 2007-08-17 | 15 | 116d |  |  | 96h |
| 44 | 1.2.5.1 | Determine audiences |  | 2d | 2007-08-15 | 2007-08-17 |  | 116d |  | End Users | 16h |
| 45 | 1.2.5.2 | Determine User Experience requirements |  | 2d? | 2007-08-15 | 2007-08-17 |  | 116d |  | End Users | 16h |
| 46 | 1.2.5.3 | Determine permission and access needs |  | 2d | 2007-08-15 | 2007-08-17 |  | 116d |  | End Users | 16h |
| 47 | 1.2.5.4 | Review/detail content management requirements |  | 2d | 2007-08-15 | 2007-08-17 |  | 116d |  | End Users | 16h |
| 48 | 1.2.5.5 | Determine content migration requirements |  | 2d? | 2007-08-15 | 2007-08-17 |  | 116d |  | End Users | 16h |
| 49 | 1.2.5.6 | Document as needed |  | 1d? | 2007-08-15 | 2007-08-16 |  | 117d |  | Project Manager | 8h |
| 50 | 1.2.5.7 | Review/detail taxonomy or content type requirements |  | 1d | 2007-08-15 | 2007-08-16 |  | 117d |  | End Users | 8h |
| 51 | 1.2.6 | **Determine Preliminary Design Objectives** |  | 8d? | 2007-08-15 | 2007-08-27 | 15 | 0d |  |  | 120h |
| 52 | 1.2.6.1 | Map vision/scope to current computing environment |  | 1d | 2007-08-15 | 2007-08-16 |  | 0d |  | Project Manager; MOSS 2007 Administrator; Intranet/Internet Administrator; End Users | 32h |
| 53 | 1.2.6.2 | Determine Microsoft Office SharePoint Server 2007 strategy |  | 1d | 2007-08-16 | 2007-08-17 | 52 | 0d |  | Project Manager; MOSS 2007 Administrator; Intranet/Internet Administrator; End Users | 32h |
| 54 | 1.2.6.3 | Determine Microsoft Office SharePoint Server 2007 storage requirements |  | 1d | 2007-08-17 | 2007-08-20 | 53 | 0d |  | MOSS 2007 Administrator; Database Administrator | 16h |
| 55 | 1.2.6.4 | Determine project information dissemination strategy (Internet, intranet, e-mail) |  | 1d | 2007-08-20 | 2007-08-21 | 54 | 0d |  | Education/Training Lead | 8h |
| 56 | 1.2.6.5 | Determine Information Architecture approach |  | 1d? | 2007-08-21 | 2007-08-22 | 55 | 0d |  | End Users | 8h |
| 57 | 1.2.6.6 | Determine branding requirements |  | 1d? | 2007-08-22 | 2007-08-23 | 56 | 0d |  | End Users | 8h |
| 58 | 1.2.6.7 | Review preliminary design objectives with executive sponsor |  | 1d | 2007-08-23 | 2007-08-24 | 57 | 0d |  | Project Manager | 8h |
| 59 | 1.2.6.8 | Document as needed |  | 1d? | 2007-08-24 | 2007-08-27 | 58 | 0d |  | Project Manager | 8h |
| 60 | 1.2.6.9 | Determine preliminary design objectives complete | milestone | 0d | 2007-08-27 | 2007-08-27 | 59 | 0d |  |  |  |

| ID | WBS | Task | Type | Duration | Start | Finish | Predecessors | Total slack | Free slack | Resources | Work |
| --- | --- | --- | --- | --- | --- | --- | --- | --- | --- | --- | --- |
| 61 | 1.2.7 | **Identify Coexistence Strategies** |  | 2d? | 2007-08-27 | 2007-08-29 | 51 | 0d |  |  | 24h |
| 62 | 1.2.7.1 | Identify interoperability issues within the company (operating systems supported, topology, protocol, etc.) |  | 1d | 2007-08-27 | 2007-08-28 |  | 1d |  | MOSS 2007 Administrator | 8h |
| 63 | 1.2.7.2 | Identify interoperability issues with the organization's partners (topology, protocol, etc.) |  | 1d | 2007-08-27 | 2007-08-28 | 58 | 0d |  | MOSS 2007 Administrator | 8h |
| 64 | 1.2.7.3 | Document as needed |  | 1d? | 2007-08-28 | 2007-08-29 | 63 | 0d |  | Project Manager | 8h |
| 65 | 1.2.7.4 | Identify coexistence strategies complete | milestone | 0d | 2007-08-29 | 2007-08-29 | 62, 64 | 0d |  |  |  |
| 66 | 1.2.8 | **Establish Test Lab Environment** |  | 4d? | 2007-08-27 | 2007-08-31 | 51 | 27d |  |  | 32h |
| 67 | 1.2.8.1 | Select one or more lab locations |  | 4h | 2007-08-27 | 2007-08-28 |  | 27d | 0d | Project Manager | 4h |
| 68 | 1.2.8.2 | Determine lab space and environmental requirements |  | 4h | 2007-08-28 | 2007-08-28 | 67 | 27d | 0d | Project Manager | 4h |
| 69 | 1.2.8.3 | Determine power and network connection requirements |  | 4h | 2007-08-28 | 2007-08-29 | 68 | 27d | 0d | MOSS 2007 Administrator | 4h |
| 70 | 1.2.8.4 | Design and document logical and physical configuration for the lab |  | 4h | 2007-08-29 | 2007-08-29 | 69 | 27d | 0d | MOSS 2007 Administrator | 4h |
| 71 | 1.2.8.5 | Determine who needs to use the lab |  | 4h | 2007-08-29 | 2007-08-30 | 70 | 27d | 0d | MOSS 2007 Administrator | 4h |
| 72 | 1.2.8.6 | Define a change control process for the lab |  | 4h | 2007-08-30 | 2007-08-30 | 71 | 27d | 0d | MOSS 2007 Administrator | 4h |
| 73 | 1.2.8.7 | Document as needed |  | 1d? | 2007-08-30 | 2007-08-31 | 72 | 27d | 0d | Project Manager | 8h |
| 74 | 1.2.8.8 | Establish test lab environment complete | milestone | 0d | 2007-08-31 | 2007-08-31 | 73 | 27d |  |  |  |
| 75 | 1.2.9 | **Perform Risk Assessment** |  | 4d | 2007-08-29 | 2007-09-04 | 61 | 25d |  |  | 32h |
| 76 | 1.2.9.1 | Identify and analyze potential risks |  | 1d | 2007-08-29 | 2007-08-30 |  | 25d | 0d | Project Manager | 8h |
| 77 | 1.2.9.2 | Quantify potential impact of the risks |  | 1d | 2007-08-30 | 2007-08-31 | 76 | 25d | 0d | Project Manager | 8h |
| 78 | 1.2.9.3 | Detail escalation processes |  | 1d | 2007-08-31 | 2007-09-03 | 77 | 25d | 0d | Project Manager | 8h |
| 79 | 1.2.9.4 | Document risk assessment |  | 1d | 2007-09-03 | 2007-09-04 | 78 | 25d | 0d | Project Manager | 8h |
| 80 | 1.2.9.5 | Perform risk assessment complete | milestone | 0d | 2007-09-04 | 2007-09-04 | 79 | 25d |  |  |  |
| 81 | 1.2.10 | **Define Communication Strategy** |  | 6d? | 2007-08-29 | 2007-09-06 | 61 | 102d |  |  | 48h |
| 82 | 1.2.10.1 | Define communication strategy for each phase |  | 1d | 2007-08-29 | 2007-08-30 |  | 102d | 0d | Project Manager | 8h |
| 83 | 1.2.10.2 | Coordinate communication strategy with business owner |  | 1d? | 2007-08-30 | 2007-08-31 | 82 | 102d | 0d | Project Manager | 8h |
| 84 | 1.2.10.3 | Define communication audiences |  | 1d | 2007-08-31 | 2007-09-03 | 83 | 102d | 0d | Project Manager | 8h |
| 85 | 1.2.10.4 | Define communication delivery mechanism |  | 1d | 2007-09-03 | 2007-09-04 | 84 | 102d | 0d | Project Manager | 8h |
| 86 | 1.2.10.5 | Establish communication timeline |  | 1d | 2007-09-04 | 2007-09-05 | 85 | 102d | 0d | Project Manager | 8h |
| 87 | 1.2.10.6 | Document communication strategy/standards |  | 1d | 2007-09-05 | 2007-09-06 | 86 | 102d | 0d | Project Manager | 8h |
| 88 | 1.2.10.7 | Define communication strategy complete | milestone | 0d | 2007-09-06 | 2007-09-06 | 87 | 102d |  |  |  |

| ID | WBS | Task | Type | Duration | Start | Finish | Predecessors | Total slack | Free slack | Resources | Work |
| --- | --- | --- | --- | --- | --- | --- | --- | --- | --- | --- | --- |
| 89 | 1.2.11 | **Define Education/Training Strategy** |  | 4d? | 2007-08-29 | 2007-09-04 | 61 | 25d |  |  | 48h |
| 90 | 1.2.11.1 | Coordinate training strategy with business owner |  | 1d? | 2007-08-29 | 2007-08-30 |  | 28d |  | Education/Training Lead | 8h |
| 91 | 1.2.11.2 | Define user assistance and help requirements |  | 1d? | 2007-08-29 | 2007-08-30 |  | 28d |  | Education/Training Lead | 8h |
| 92 | 1.2.11.3 | Define education strategy for deployment demographics (administrators, help desk, end-users) |  | 1d | 2007-08-29 | 2007-08-30 |  | 25d | 0d | Education/Training Lead | 8h |
| 93 | 1.2.11.4 | Define education delivery mechanism |  | 1d | 2007-08-30 | 2007-08-31 | 92 | 25d | 0d | Education/Training Lead | 8h |
| 94 | 1.2.11.5 | Establish education timeline by phase |  | 1d | 2007-08-31 | 2007-09-03 | 93 | 25d | 0d | Education/Training Lead | 8h |
| 95 | 1.2.11.6 | Document education strategy/standards |  | 1d | 2007-09-03 | 2007-09-04 | 94 | 25d | 0d | Education/Training Lead | 8h |
| 96 | 1.2.11.7 | Define education/training strategy complete | milestone | 0d | 2007-09-04 | 2007-09-04 | 95 | 25d |  | Education/Training Lead |  |
| 97 | 1.2.12 | **Review Client Software and Hardware** |  | 23d? | 2007-08-29 | 2007-10-01 | 61 | 6d |  |  | 184h |
| 98 | 1.2.12.1 | Determine existing hardware and compare to client hardware requirements |  | 5d | 2007-08-29 | 2007-09-05 |  | 6d | 0d | Desktop Administrator | 40h |
| 99 | 1.2.12.2 | Determine existing operating systems and software and compare to software requirements |  | 5d | 2007-09-05 | 2007-09-12 | 98 | 6d | 0d | Desktop Administrator | 40h |
| 100 | 1.2.12.3 | Determine if upgrade to MS Office System 2007 is beneficial |  | 1d? | 2007-09-12 | 2007-09-13 | 99 | 6d | 0d | Desktop Administrator | 8h |
| 101 | 1.2.12.4 | Review browser requirements |  | 1d? | 2007-09-13 | 2007-09-14 | 100 | 6d | 0d | Desktop Administrator | 8h |
| 102 | 1.2.12.5 | Upgrade client hardware and software as needed |  | 10d | 2007-09-14 | 2007-09-28 | 101 | 6d | 0d | Desktop Administrator | 80h |
| 103 | 1.2.12.6 | Document as needed |  | 1d? | 2007-09-28 | 2007-10-01 | 102 | 6d | 0d | Desktop Administrator | 8h |
| 104 | 1.2.12.7 | Plan client deployment complete | milestone | 0d | 2007-10-01 | 2007-10-01 | 103 | 6d |  |  |  |
| 105 | 1.2.13 | **Create Governance Plan with Mission, Vision and Strategy** |  | 1d? | 2007-08-10 | 2007-08-13 |  | 120d |  |  |  |
| 106 | 1.2.13.1 | Plan information portal and site collection taxonomies and heirarchies |  | 1d? | 2007-08-10 | 2007-08-13 |  | 120d |  |  |  |
| 107 | 1.2.13.2 | Plan information policy and file plan as applicable |  | 1d? | 2007-08-10 | 2007-08-13 |  | 120d |  |  |  |
| 108 | 1.2.13.3 | Plan branding approach |  | 1d? | 2007-08-10 | 2007-08-13 |  | 120d |  |  |  |
| 109 | 1.2.13.4 | Plan structure |  | 1d? | 2007-08-10 | 2007-08-13 |  | 120d |  |  |  |
| 110 | 1.2.13.5 | Plan information security policies |  | 1d? | 2007-08-10 | 2007-08-13 |  | 120d |  |  |  |
| 111 | 1.2.14 | **Plan Server Configuration** |  | 15d? | 2007-08-29 | 2007-09-19 | 61 | 0d |  |  | 264h |
| 112 | 1.2.14.1 | Identify document management approach |  | 1d | 2007-08-29 | 2007-08-30 |  | 28d |  | Intranet/Internet Administrator | 8h |
| 113 | 1.2.14.2 | Identify existing content sources (content audit or inventory) |  | 3d | 2007-08-29 | 2007-09-03 |  | 26d |  | Intranet/Internet Administrator | 24h |
| 114 | 1.2.14.3 | Determine content migration methodology |  | 1d? | 2007-08-29 | 2007-08-30 |  | 28d |  | Intranet/Internet Administrator | 8h |
| 115 | 1.2.14.4 | Review server software requirements |  | 1d | 2007-08-29 | 2007-08-30 |  | 28d |  | Intranet/Internet Administrator | 8h |
| 116 | 1.2.14.5 | Determine redirect hosting requirements |  | 1d? | 2007-08-29 | 2007-08-30 |  | 28d |  | Intranet/Internet Administrator | 8h |
| 117 | 1.2.14.6 | Determine LDAP vs. AD for authentication |  | 1d? | 2007-08-29 | 2007-08-30 |  | 28d |  | Intranet/Internet Administrator | 8h |
| 118 | 1.2.14.7 | Plan for Anonymous users |  | 1d? | 2007-08-29 | 2007-08-30 |  | 28d |  | Intranet/Internet Administrator | 8h |
| 119 | 1.2.14.8 | Plan Recycle Bin use and Site recovery |  | 1d? | 2007-08-29 | 2007-08-30 |  | 28d |  | Intranet/Internet Administrator | 8h |
| 120 | 1.2.14.9 | Determine site provisioning model and user experience |  | 1d? | 2007-08-29 | 2007-08-30 |  | 28d |  | End Users | 8h |

| ID | WBS | Task | Type | Duration | Start | Finish | Predecessors | Total slack | Free slack | Resources | Work |
| --- | --- | --- | --- | --- | --- | --- | --- | --- | --- | --- | --- |
| 121 | 1.2.14.10 | **Determine Roles and Usage Patterns of Users** |  | 2d | 2007-08-29 | 2007-08-31 |  | 0d |  |  | 48h |
| 122 | 1.2.14.10.1 | Identify number and anticipated usage patterns of users of the Web front end |  | 2d | 2007-08-29 | 2007-08-31 |  | 0d |  | Project Manager | 16h |
| 123 | 1.2.14.10.2 | Identify number and anticipated usage patterns of document management users |  | 2d | 2007-08-29 | 2007-08-31 |  | 0d |  | Project Manager | 16h |
| 124 | 1.2.14.10.3 | Identify number and anticipated usage patterns of search users |  | 2d | 2007-08-29 | 2007-08-31 |  | 0d |  | Project Manager | 16h |
| 125 | 1.2.14.11 | **Plan Capacity** |  | 13d | 2007-08-31 | 2007-09-19 | 121 | 0d |  |  | 120h |
| 126 | 1.2.14.11.1 | Determine normal load from roles and usage patterns |  | 2d | 2007-08-31 | 2007-09-04 |  | 0d |  | Intranet/Internet Administrator | 16h |
| 127 | 1.2.14.11.2 | Determine number of documents stored and document store size |  | 2d | 2007-09-04 | 2007-09-06 | 126 | 0d |  | Intranet/Internet Administrator | 16h |
| 128 | 1.2.14.11.3 | Estimate index size |  | 1d | 2007-09-06 | 2007-09-07 | 127 | 0d |  | Intranet/Internet Administrator | 8h |
| 129 | 1.2.14.11.4 | Determine needs for growth |  | 1d | 2007-09-07 | 2007-09-10 | 128 | 0d |  | MOSS 2007 Administrator; Intranet/Internet Administrator; Database Administrator | 24h |
| 130 | 1.2.14.11.5 | Determine peak load factor |  | 1d | 2007-09-10 | 2007-09-11 | 129 | 0d |  | Intranet/Internet Administrator | 8h |
| 131 | 1.2.14.11.6 | Determine approach between single server, server farm, or shared services |  | 2d | 2007-09-11 | 2007-09-13 | 130 | 0d |  | Intranet/Internet Administrator | 16h |
| 132 | 1.2.14.11.7 | Evaluate caching, load balancing, and other scaling techniques |  | 1d | 2007-09-13 | 2007-09-14 | 131 | 0d |  | MOSS 2007 Administrator | 8h |
| 133 | 1.2.14.11.8 | Determine future scale-out approach |  | 2d | 2007-09-14 | 2007-09-18 | 132 | 0d |  | Intranet/Internet Administrator | 16h |
| 134 | 1.2.14.11.9 | Draw system architecture |  | 1d | 2007-09-18 | 2007-09-19 | 133 | 0d |  | Intranet/Internet Administrator | 8h |
| 135 | 1.2.14.12 | Document as needed |  | 1d? | 2007-08-29 | 2007-08-30 |  | 28d |  | MOSS 2007 Administrator | 8h |
| 136 | 1.2.14.13 | Plan server configuration complete | milestone | 0d | 2007-09-19 | 2007-09-19 | 134 | 14d |  |  |  |
| 137 | 1.2.15 | **Plan Security** |  | 1d? | 2007-08-29 | 2007-08-30 | 61 | 28d |  |  | 152h |
| 138 | 1.2.15.1 | **Determine Microsoft Office SharePoint Server 2007 Roles** |  | 1d | 2007-08-29 | 2007-08-30 |  | 28d | 0d |  | 8h |
| 139 | 1.2.15.1.1 | Assign user role to provide permission to user to perform specific tasks |  | 1d | 2007-08-29 | 2007-08-30 |  | 28d |  | MOSS 2007 Administrator | 8h |
| 140 | 1.2.15.2 | **Define Content Security Strategy** |  | 1d | 2007-08-29 | 2007-08-30 |  | 28d | 0d |  | 8h |
| 141 | 1.2.15.2.1 | Utilize role-based security to control user access to content |  | 1d | 2007-08-29 | 2007-08-30 |  | 28d |  | MOSS 2007 Administrator | 8h |
| 142 | 1.2.15.3 | **Security Review and Lockdown** |  | 1d? | 2007-08-29 | 2007-08-30 |  | 28d |  |  | 88h |
| 143 | 1.2.15.3.1 | Detailed review of Use Cases from threat model |  | 1d? | 2007-08-29 | 2007-08-30 |  | 28d |  | MOSS 2007 Administrator | 8h |
| 144 | 1.2.15.3.2 | Determine Authentication provider - AD versus LDAP |  | 1d? | 2007-08-29 | 2007-08-30 |  | 28d |  | MOSS 2007 Administrator | 8h |
| 145 | 1.2.15.3.3 | Server and Application Hardening |  | 1d? | 2007-08-29 | 2007-08-30 |  | 28d |  | MOSS 2007 Administrator | 8h |
| 146 | 1.2.15.3.4 | Review Security Requirements |  | 1d? | 2007-08-29 | 2007-08-30 |  | 28d |  | MOSS 2007 Administrator | 8h |
| 147 | 1.2.15.3.5 | Review AD groups |  | 1d? | 2007-08-29 | 2007-08-30 |  | 28d |  | MOSS 2007 Administrator | 8h |
| 148 | 1.2.15.3.6 | Review security design |  | 1d? | 2007-08-29 | 2007-08-30 |  | 28d |  | MOSS 2007 Administrator | 8h |
| 149 | 1.2.15.3.7 | Review Use Cases and Identify Data Classification |  | 1d? | 2007-08-29 | 2007-08-30 |  | 28d |  | MOSS 2007 Administrator | 8h |
| 150 | 1.2.15.3.8 | Review & Update CRUD diagrams |  | 1d? | 2007-08-29 | 2007-08-30 |  | 28d |  | MOSS 2007 Administrator | 8h |
| 151 | 1.2.15.3.9 | Review Infrastructure components |  | 1d? | 2007-08-29 | 2007-08-30 |  | 28d |  | MOSS 2007 Administrator | 8h |
| 152 | 1.2.15.3.10 | Identify and document threats |  | 1d? | 2007-08-29 | 2007-08-30 |  | 28d |  | MOSS 2007 Administrator | 8h |
| 153 | 1.2.15.3.11 | Document Security Model |  | 1d? | 2007-08-29 | 2007-08-30 |  | 28d |  | MOSS 2007 Administrator | 8h |

| ID | WBS | Task | Type | Duration | Start | Finish | Predecessors | Total slack | Free slack | Resources | Work |
| --- | --- | --- | --- | --- | --- | --- | --- | --- | --- | --- | --- |
| 154 | 1.2.15.4 | **Identify Security Measures for Connecting to the Internet** |  | 1d? | 2007-08-29 | 2007-08-30 |  | 28d | 0d |  | 40h |
| 155 | 1.2.15.4.1 | Evaluate using SSL |  | 1d | 2007-08-29 | 2007-08-30 |  | 28d |  | Intranet/Internet Administrator | 8h |
| 156 | 1.2.15.4.2 | Evaluate techniques to prevent unauthorized access |  | 1d | 2007-08-29 | 2007-08-30 |  | 28d |  | Intranet/Internet Administrator | 8h |
| 157 | 1.2.15.4.3 | Determine web application policies |  | 1d? | 2007-08-29 | 2007-08-30 |  | 28d |  | Intranet/Internet Administrator | 8h |
| 158 | 1.2.15.4.4 | Review compliance requirements |  | 1d? | 2007-08-29 | 2007-08-30 |  | 28d |  | Intranet/Internet Administrator | 8h |
| 159 | 1.2.15.4.5 | Determine Information Policies |  | 1d? | 2007-08-29 | 2007-08-30 |  | 28d |  | Intranet/Internet Administrator | 8h |
| 160 | 1.2.15.5 | Document as needed |  | 1d? | 2007-08-29 | 2007-08-30 |  | 28d |  | Intranet/Internet Administrator | 8h |
| 161 | 1.2.15.6 | Security planning complete | milestone | 0d | 2007-08-30 | 2007-08-30 | 138, 140, 154 | 28d |  |  |  |
| 162 | 1.2.16 | **Plan for Performance** |  | 14d? | 2007-09-19 | 2007-10-09 | 61, 125 | 0d |  |  | 136h |
| 163 | 1.2.16.1 | **Performance testing of major components of MOSS** |  | 1d? | 2007-09-19 | 2007-09-20 |  | 13d |  |  | 24h |
| 164 | 1.2.16.1.1 | My Sites |  | 1d? | 2007-09-19 | 2007-09-20 |  | 13d |  | MOSS 2007 Administrator | 8h |
| 165 | 1.2.16.1.2 | Determine requests per second |  | 1d? | 2007-09-19 | 2007-09-20 |  | 13d |  | MOSS 2007 Administrator | 8h |
| 166 | 1.2.16.1.3 | Measure caching performance and optimizations |  | 1d? | 2007-09-19 | 2007-09-20 |  | 13d |  | MOSS 2007 Administrator | 8h |
| 167 | 1.2.16.2 | Review connectivity and bandwidth requirements |  | 2d | 2007-09-19 | 2007-09-21 |  | 0d |  | MOSS 2007 Administrator | 16h |
| 168 | 1.2.16.3 | Review current network |  | 2d | 2007-09-21 | 2007-09-25 | 167 | 0d |  | MOSS 2007 Administrator | 16h |
| 169 | 1.2.16.4 | Establishing minimum performance levels |  | 1d? | 2007-09-25 | 2007-09-26 | 168 | 0d |  | MOSS 2007 Administrator | 8h |
| 170 | 1.2.16.5 | Performance testing of network |  | 1d? | 2007-09-26 | 2007-09-27 | 169 | 0d |  | MOSS 2007 Administrator | 8h |
| 171 | 1.2.16.6 | Review network performance |  | 1d? | 2007-09-27 | 2007-09-28 | 170 | 0d |  | MOSS 2007 Administrator | 8h |
| 172 | 1.2.16.7 | Diagram future network topology |  | 2d | 2007-09-28 | 2007-10-02 | 171 | 0d |  | MOSS 2007 Administrator | 16h |
| 173 | 1.2.16.8 | Upgrade WAN and LAN as required |  | 5d | 2007-10-02 | 2007-10-09 | 172 | 0d |  | MOSS 2007 Administrator | 40h |
| 174 | 1.2.17 | Document as needed |  | 1d? | 2007-08-10 | 2007-08-13 |  | 120d |  | MOSS 2007 Administrator | 8h |
| 175 | 1.2.18 | Plan for network upgrades and WAN considerations | milestone | 0d | 2007-10-09 | 2007-10-09 | 173 | 79d |  |  |  |
| 176 | 1.2.19 | **Plan failover and disaster recovery** |  | 1d? | 2007-08-10 | 2007-08-13 |  | 120d |  |  | 40h |
| 177 | 1.2.19.1 | Establish failover and disaster recovery requirements |  | 1d? | 2007-08-10 | 2007-08-13 |  | 120d |  | MOSS 2007 Administrator | 8h |
| 178 | 1.2.19.2 | Create Failover and disaster recover plan |  | 1d? | 2007-08-10 | 2007-08-13 |  | 120d |  | MOSS 2007 Administrator | 8h |
| 179 | 1.2.19.3 | Determine need for Microsoft Data Protection Manager (DPM) |  | 1d? | 2007-08-10 | 2007-08-13 |  | 120d |  | MOSS 2007 Administrator | 8h |
| 180 | 1.2.19.4 | Plan Recycle Bin use and Site recovery plans |  | 1d? | 2007-08-10 | 2007-08-13 |  | 120d |  | MOSS 2007 Administrator | 8h |
| 181 | 1.2.19.5 | Document as needed |  | 1d? | 2007-08-10 | 2007-08-13 |  | 120d |  | MOSS 2007 Administrator | 8h |

| ID | WBS | Task | Type | Duration | Start | Finish | Predecessors | Total slack | Free slack | Resources | Work |
| --- | --- | --- | --- | --- | --- | --- | --- | --- | --- | --- | --- |
| 182 | 1.2.20 | **Plan for Localization** |  | 5d? | 2007-08-29 | 2007-09-05 | 61 | 24d |  |  | 56h |
| 183 | 1.2.20.1 | Determine language used for server farm |  | 1d | 2007-08-29 | 2007-08-30 |  | 24d | 0d | MOSS 2007 Administrator | 8h |
| 184 | 1.2.20.2 | Determine need for Variations |  | 1d? | 2007-08-30 | 2007-08-31 | 183 | 24d | 0d | MOSS 2007 Administrator | 8h |
| 185 | 1.2.20.3 | Install needed language packs |  | 1d? | 2007-08-31 | 2007-09-03 | 184 | 24d | 0d | MOSS 2007 Administrator | 8h |
| 186 | 1.2.20.4 | Review search settings for locale |  | 2d | 2007-09-03 | 2007-09-05 | 185 | 24d | 0d | MOSS 2007 Administrator | 16h |
| 187 | 1.2.20.5 | Review language consideration for Microsoft Windows SharePoint Services |  | 2d | 2007-08-29 | 2007-08-31 |  | 27d | 3d | MOSS 2007 Administrator | 16h |
| 188 | 1.2.20.6 | Document as needed | milestone | 0d | 2007-09-05 | 2007-09-05 | 186, 187 | 24d |  | MOSS 2007 Administrator |  |
| 189 | 1.2.20.7 | Plan for localization complete |  | 1d? | 2007-08-29 | 2007-08-30 |  | 28d |  |  |  |
| 190 | 1.2.21 | **Plan Integration** |  | 10d? | 2007-08-29 | 2007-09-12 | 61 | 19d |  |  | 184h |
| 191 | 1.2.21.1 | Plan Windows SharePoint Services deployment (complete planning tasks in the Windows SharePoint Services Deployment template) |  | 5d | 2007-08-29 | 2007-09-05 |  | 24d | 5d | MOSS 2007 Administrator | 40h |
| 192 | 1.2.21.2 | **Business Data Catalog (BDC)** |  | 1d? | 2007-08-29 | 2007-08-30 |  | 28d |  |  | 8h |
| 193 | 1.2.21.2.1 | Determine need for Integration with Microsoft Business Data Catalog (BDC) |  | 1d? | 2007-08-29 | 2007-08-30 |  | 28d |  | MOSS 2007 Administrator | 8h |
| 194 | 1.2.21.3 | **Excel Services** |  | 1d? | 2007-08-29 | 2007-08-30 |  | 28d |  |  | 8h |
| 195 | 1.2.21.3.1 | Determine need for Excel Services |  | 1d? | 2007-08-29 | 2007-08-30 |  | 28d |  | MOSS 2007 Administrator | 8h |
| 196 | 1.2.21.4 | **Forms Server** |  | 1d? | 2007-08-29 | 2007-08-30 |  | 28d |  |  | 8h |
| 197 | 1.2.21.4.1 | Determine need for Forms Server |  | 1d? | 2007-08-29 | 2007-08-30 |  | 28d |  | MOSS 2007 Administrator | 8h |
| 198 | 1.2.21.5 | **MOSS 2007 for Search** |  | 1d? | 2007-08-29 | 2007-08-30 |  | 28d |  |  | 8h |
| 199 | 1.2.21.5.1 | Determine need for MOSS 2007 for Search |  | 1d? | 2007-08-29 | 2007-08-30 |  | 28d |  | MOSS 2007 Administrator | 8h |
| 200 | 1.2.21.6 | **Forefront Security for SharePoint** |  | 1d? | 2007-08-29 | 2007-08-30 |  | 28d |  |  | 8h |
| 201 | 1.2.21.6.1 | Determine need for Forefront Security for MOSS 2007 |  | 1d? | 2007-08-29 | 2007-08-30 |  | 28d |  | MOSS 2007 Administrator | 8h |
| 202 | 1.2.21.7 | **Windows SharePoint Services** |  | 1d? | 2007-08-29 | 2007-08-30 |  | 28d |  |  | 8h |
| 203 | 1.2.21.7.1 | Determine need for WSS 3.0 |  | 1d? | 2007-08-29 | 2007-08-30 |  | 28d |  | MOSS 2007 Administrator | 8h |
| 204 | 1.2.21.8 | **Microsoft Office Groove Server 2007** |  | 1d? | 2007-08-29 | 2007-08-30 |  | 28d |  |  | 8h |
| 205 | 1.2.21.8.1 | Determine need for Groove Server 2007 |  | 1d? | 2007-08-29 | 2007-08-30 |  | 28d |  | MOSS 2007 Administrator | 8h |
| 206 | 1.2.21.9 | Plan for incoming email |  | 1d? | 2007-08-29 | 2007-08-30 |  | 28d |  | MOSS 2007 Administrator | 8h |
| 207 | 1.2.21.10 | Identify other systems for integration |  | 2d | 2007-08-29 | 2007-08-31 |  | 19d | 0d | MOSS 2007 Administrator | 16h |
| 208 | 1.2.21.11 | Determine integration strategy |  | 2d | 2007-08-31 | 2007-09-04 | 207 | 19d | 0d | MOSS 2007 Administrator | 16h |
| 209 | 1.2.21.12 | Develop plan for integration |  | 5d | 2007-09-04 | 2007-09-11 | 208 | 19d | 0d | MOSS 2007 Administrator | 40h |
| 210 | 1.2.21.13 | Document as needed |  | 1d? | 2007-09-11 | 2007-09-12 | 209 | 19d | 0d | MOSS 2007 Administrator | 8h |
| 211 | 1.2.21.14 | Plan integration complete | milestone | 0d | 2007-09-12 | 2007-09-12 | 191, 210 | 19d |  |  |  |

| ID | WBS | Task | Type | Duration | Start | Finish | Predecessors | Total slack | Free slack | Resources | Work |
| --- | --- | --- | --- | --- | --- | --- | --- | --- | --- | --- | --- |
| 212 | 1.2.22 | **Plan Maintenance** |  | 2d? | 2007-08-29 | 2007-08-31 | 61 | 27d |  |  | 64h |
| 213 | 1.2.22.1 | Plan backup and restore |  | 2d | 2007-08-29 | 2007-08-31 |  | 27d | 0d | MOSS 2007 Administrator | 16h |
| 214 | 1.2.22.2 | Plan other routine maintenance |  | 2d | 2007-08-29 | 2007-08-31 |  | 27d | 0d | MOSS 2007 Administrator | 16h |
| 215 | 1.2.22.3 | Determine quotas to manage site collection storage sizes |  | 1d? | 2007-08-29 | 2007-08-30 |  | 28d |  | MOSS 2007 Administrator | 8h |
| 216 | 1.2.22.4 | Configure zones, alternate acces mappings, etc. |  | 1d? | 2007-08-29 | 2007-08-30 |  | 28d |  | MOSS 2007 Administrator | 8h |
| 217 | 1.2.22.5 | Determine site use confirmation and deletion to manage unused site collections / notification schedule |  | 1d? | 2007-08-29 | 2007-08-30 |  | 28d |  | MOSS 2007 Administrator | 8h |
| 218 | 1.2.22.6 | Document as needed |  | 1d? | 2007-08-29 | 2007-08-30 |  | 28d |  | MOSS 2007 Administrator | 8h |
| 219 | 1.2.22.7 | Plan maintenance complete | milestone | 0d | 2007-08-31 | 2007-08-31 | 213, 214 | 27d |  |  |  |
| 220 | 1.2.23 | **Plan Content and Navigation Structure** |  | 1d? | 2007-08-10 | 2007-08-13 |  | 120d |  |  | 48h |
| 221 | 1.2.23.1 | Create detailed wireframes for site and page structure |  | 1d? | 2007-08-10 | 2007-08-13 |  | 120d |  | End Users | 8h |
| 222 | 1.2.23.2 | Identify additional content and design requirements |  | 1d? | 2007-08-10 | 2007-08-13 |  | 120d |  | End Users | 8h |
| 223 | 1.2.23.3 | Identify custom development requirements |  | 1d? | 2007-08-10 | 2007-08-13 |  | 120d |  | End Users | 8h |
| 224 | 1.2.23.4 | Establish and maintain user experience best practice guidelines |  | 1d? | 2007-08-10 | 2007-08-13 |  | 120d |  | End Users | 8h |
| 225 | 1.2.23.5 | Establish content type / page layout creation review group |  | 1d? | 2007-08-10 | 2007-08-13 |  | 120d |  | End Users | 8h |
| 226 | 1.2.23.6 | Maintain brand consistency and design standards for templates |  | 1d? | 2007-08-10 | 2007-08-13 |  | 120d |  | End Users | 8h |
| 227 | 1.2.24 | Document as needed |  | 1d? | 2007-08-10 | 2007-08-13 |  | 120d |  | Project Manager | 8h |
| 228 | 1.2.25 | Planning complete | milestone | 0d | 2007-10-09 | 2007-10-09 | 74, 80, 162, 182, 190, 212, 137, 89, 97, 111 | 0d |  |  |  |
| 229 | 1.2.26 | Deployment approved | milestone | 0d | 2007-10-09 | 2007-10-09 | 228 | 0d |  |  |  |
| 230 | 1.3 | **Deployment, Implementation and Configuration Management** |  | 47d? | 2007-10-09 | 2007-12-13 | 229 | 0d |  |  | 1536h |
| 231 | 1.3.1 | **Deploy Pilot System** |  | 5d? | 2007-10-09 | 2007-10-16 |  | 0d |  |  | 168h |
| 232 | 1.3.1.1 | Install Hardware |  | 1d? | 2007-10-09 | 2007-10-10 |  | 46d |  |  |  |
| 233 | 1.3.1.2 | **Install Software** |  | 1d? | 2007-10-09 | 2007-10-10 |  | 46d |  |  | 8h |
| 234 | 1.3.1.2.1 | **Configure Software** |  | 1d? | 2007-10-09 | 2007-10-10 |  | 46d |  |  | 8h |
| 235 | 1.3.1.2.1.1 | Configure Search |  | 1d? | 2007-10-09 | 2007-10-10 |  | 46d |  | MOSS 2007 Administrator | 8h |

| ID | WBS | Task | Type | Duration | Start | Finish | Predecessors | Total slack | Free slack | Resources | Work |
| --- | --- | --- | --- | --- | --- | --- | --- | --- | --- | --- | --- |
| 236 | 1.3.1.3 | **Test and Evaluate Pilot** |  | 5d | 2007-10-09 | 2007-10-16 |  | 0d |  |  | 160h |
| 237 | 1.3.1.3.1 | Test MOSS 2007 |  | 5d | 2007-10-09 | 2007-10-16 |  | 0d |  | Test/QA Lead | 40h |
| 238 | 1.3.1.3.2 | Test search and index |  | 5d | 2007-10-09 | 2007-10-16 |  | 0d |  | Test/QA Lead | 40h |
| 239 | 1.3.1.3.3 | Test features and solutions |  | 5d | 2007-10-09 | 2007-10-16 |  | 0d |  | Test/QA Lead | 40h |
| 240 | 1.3.1.3.4 | Test custom integration |  | 5d | 2007-10-09 | 2007-10-16 |  | 0d |  | Test/QA Lead | 40h |
| 241 | 1.3.1.4 | Deploy pilot system complete | milestone | 0d | 2007-10-16 | 2007-10-16 | 236 | 0d |  |  |  |
| 242 | 1.3.1.5 | Production deployment approved | milestone | 0d | 2007-10-16 | 2007-10-16 | 241 | 0d |  |  |  |
| 243 | 1.3.2 | Deploy applicable Dev, Test, Staging environments |  | 5d | 2007-10-16 | 2007-10-23 | 242 | 0d |  | MOSS 2007 Administrator | 40h |
| 244 | 1.3.3 | User acceptance and business requirements signoff |  | 1d? | 2007-10-23 | 2007-10-24 | 243 | 0d |  |  |  |
| 245 | 1.3.4 | Production Go/No-Go Decision |  | 1d? | 2007-10-24 | 2007-10-25 | 244 | 0d |  |  |  |
| 246 | 1.3.5 | **Deploy Production System** |  | 35d? | 2007-10-25 | 2007-12-13 | 245 | 0d |  |  | 1328h |
| 247 | 1.3.5.1 | **Install Hardware** |  | 4d? | 2007-10-25 | 2007-10-31 |  | 0d |  |  | 40h |
| 248 | 1.3.5.1.1 | Order new hardware as required |  | 2d | 2007-10-25 | 2007-10-29 |  | 0d |  | MOSS 2007 Administrator | 16h |
| 249 | 1.3.5.1.2 | Configure new hardware |  | 2d | 2007-10-29 | 2007-10-31 | 248 | 0d |  | MOSS 2007 Administrator | 16h |
| 250 | 1.3.5.1.3 | Document as needed |  | 1d? | 2007-10-25 | 2007-10-26 |  | 34d |  | MOSS 2007 Administrator | 8h |
| 251 | 1.3.5.2 | **Install Software** |  | 26d? | 2007-10-31 | 2007-12-06 | 249 | 0d |  |  | 776h |
| 252 | 1.3.5.2.1 | Install operating system(s) and prerequisites (.NET, etc.) |  | 1d | 2007-10-31 | 2007-11-01 |  | 24d | 0d | MOSS 2007 Administrator | 8h |
| 253 | 1.3.5.2.2 | Setup load balancing solution |  | 1d | 2007-11-01 | 2007-11-02 | 252 | 24d |  | MOSS 2007 Administrator | 8h |
| 254 | 1.3.5.2.3 | Install operating system(s) |  | 1d | 2007-10-31 | 2007-11-01 |  | 0d |  | MOSS 2007 Administrator | 8h |
| 255 | 1.3.5.2.4 | Install Windows SharePoint Services |  | 1d | 2007-11-01 | 2007-11-02 | 254 | 0d |  | MOSS 2007 Administrator | 8h |
| 256 | 1.3.5.2.5 | Setup network load balancing |  | 1d | 2007-11-02 | 2007-11-05 | 255 | 0d |  | MOSS 2007 Administrator | 8h |
| 257 | 1.3.5.2.6 | Install Microsoft Office SharePoint Server 2007 |  | 1d | 2007-11-05 | 2007-11-06 | 256 | 0d |  | MOSS 2007 Administrator | 8h |
| 258 | 1.3.5.2.7 | Install SQL Server |  | 1d | 2007-11-06 | 2007-11-07 | 257 | 0d |  | Database Administrator | 8h |
| 259 | 1.3.5.2.8 | Install any failover/disaster recovery software |  | 1d? | 2007-11-07 | 2007-11-08 | 258 | 0d |  | MOSS 2007 Administrator | 8h |
| 260 | 1.3.5.2.9 | Install Microsoft Data Protection Manager (DPM) if needed |  | 1d? | 2007-11-08 | 2007-11-09 | 259 | 0d |  | MOSS 2007 Administrator | 8h |
| 261 | 1.3.5.2.10 | Install SharePoint management pack for MOM if needed |  | 1d? | 2007-11-09 | 2007-11-12 | 260 | 0d |  | MOSS 2007 Administrator | 8h |
| 262 | 1.3.5.2.11 | Configure Web front end server(s) |  | 1d | 2007-11-12 | 2007-11-13 | 261 | 0d |  | MOSS 2007 Administrator | 8h |
| 263 | 1.3.5.2.12 | Configure index and query services |  | 1d | 2007-11-13 | 2007-11-14 | 262 | 0d |  | MOSS 2007 Administrator | 8h |
| 264 | 1.3.5.2.13 | Configure search server (if large farm deployment) |  | 1d | 2007-11-14 | 2007-11-15 | 263 | 0d |  | MOSS 2007 Administrator | 8h |
| 265 | 1.3.5.2.14 | Configure application servers (if topology requires) |  | 1d? | 2007-11-15 | 2007-11-16 | 264 | 14d |  | MOSS 2007 Administrator | 8h |
| 266 | 1.3.5.2.15 | Install and register filters / ifilters |  | 1d? | 2007-10-31 | 2007-11-01 |  | 25d |  | MOSS 2007 Administrator | 8h |
| 267 | 1.3.5.2.16 | Document as needed |  | 1d? | 2007-10-31 | 2007-11-01 |  | 25d |  | MOSS 2007 Administrator | 8h |

| ID | WBS | Task | Duration | Start | Finish | Predecessors | Total slack | Free slack | Resources | Work |
| --- | --- | --- | --- | --- | --- | --- | --- | --- | --- | --- |
| 268 | 1.3.5.2.17 | **Configure Software** | 15d? | 2007-11-15 | 2007-12-06 | 264 | 0d |  |  | 648h |
| 269 | 1.3.5.2.17.1 | Configure site templates | 1d? | 2007-11-15 | 2007-11-16 |  | 12d | 0d | Workspace Coordinators | 8h |
| 270 | 1.3.5.2.17.2 | Apply branding and design elements | 1d? | 2007-11-16 | 2007-11-19 | 269 | 12d | 0d | Workspace Coordinators | 8h |
| 271 | 1.3.5.2.17.3 | Configure e-mail settings | 1d | 2007-11-19 | 2007-11-20 | 270 | 12d |  | Workspace Coordinators | 8h |
| 272 | 1.3.5.2.17.4 | Configure usage analysis | 1d | 2007-11-15 | 2007-11-16 |  | 14d |  | Intranet/Internet Administrator | 8h |
| 273 | 1.3.5.2.17.5 | Configure antivirus protection | 1d | 2007-11-15 | 2007-11-16 |  | 14d |  | Intranet/Internet Administrator | 8h |
| 274 | 1.3.5.2.17.6 | Configure blocked files | 1d | 2007-11-15 | 2007-11-16 |  | 14d |  | Workspace Coordinators | 8h |
| 275 | 1.3.5.2.17.7 | Configure security | 3d | 2007-11-15 | 2007-11-20 |  | 12d |  | Workspace Coordinators | 24h |
| 276 | 1.3.5.2.17.8 | Configure user profiles | 3d | 2007-11-15 | 2007-11-20 |  | 12d |  | Workspace Coordinators | 24h |
| 277 | 1.3.5.2.17.9 | Configure audiences | 2d | 2007-11-15 | 2007-11-19 |  | 13d |  | Workspace Coordinators | 16h |
| 278 | 1.3.5.2.17.10 | Configure SSL | 1d? | 2007-11-15 | 2007-11-16 |  | 14d |  | Workspace Coordinators | 8h |
| 279 | 1.3.5.2.17.11 | Configure ISA/Firewalls | 1d? | 2007-11-15 | 2007-11-16 |  | 14d |  | Workspace Coordinators | 8h |
| 280 | 1.3.5.2.17.12 | Set web application quota templates and choose site collection quotas | 1d? | 2007-11-15 | 2007-11-16 |  | 14d |  | Workspace Coordinators | 8h |
| 281 | 1.3.5.2.17.13 | Configure CAS/Security Levels | 1d? | 2007-11-15 | 2007-11-16 |  | 14d |  | Workspace Coordinators | 8h |
| 282 | 1.3.5.2.17.14 | Determine self service site provisioning | 1d? | 2007-11-15 | 2007-11-16 |  | 14d |  | Workspace Coordinators | 8h |
| 283 | 1.3.5.2.17.15 | Configure permissions and information policies | 1d? | 2007-11-15 | 2007-11-16 |  | 14d |  | Workspace Coordinators | 8h |
| 284 | 1.3.5.2.17.16 | Configure WSS and MOSS usage reporting | 1d? | 2007-11-15 | 2007-11-16 |  | 14d |  | Workspace Coordinators | 8h |
| 285 | 1.3.5.2.17.17 | Configure any software being integrated with MOSS 2007 | 1d? | 2007-11-15 | 2007-11-16 |  | 14d |  | Workspace Coordinators | 8h |
| 286 | 1.3.5.2.17.18 | Configure Recycle Bin retention and Site Delete Confirmation | 1d? | 2007-11-15 | 2007-11-16 |  | 14d |  | Workspace Coordinators | 8h |
| 287 | 1.3.5.2.17.19 | Deploy custom solutions and features | 1d? | 2007-11-15 | 2007-11-16 |  | 14d |  | Workspace Coordinators | 8h |
| 288 | 1.3.5.2.17.20 | Document as needed | 1d? | 2007-11-15 | 2007-11-16 |  | 14d |  | Workspace Coordinators | 8h |
| 289 | 1.3.5.2.17.21 | **Configure Search** | 3d? | 2007-11-15 | 2007-11-20 |  | 12d |  |  | 88h |
| 290 | 1.3.5.2.17.21.1 | Install and register filters | 1d | 2007-11-15 | 2007-11-16 |  | 14d |  | Workspace Coordinators | 8h |
| 291 | 1.3.5.2.17.21.2 | Configure content locations | 2d | 2007-11-15 | 2007-11-19 |  | 13d |  | Workspace Coordinators | 16h |
| 292 | 1.3.5.2.17.21.3 | Modify noise word and thesaurus files and create custom search queries | 3d | 2007-11-15 | 2007-11-20 |  | 12d |  | Workspace Coordinators | 24h |
| 293 | 1.3.5.2.17.21.4 | Maintenance for indexing | 1d? | 2007-11-15 | 2007-11-16 |  | 14d |  | Workspace Coordinators | 8h |
| 294 | 1.3.5.2.17.21.5 | Configure best bets and keywords for search | 1d? | 2007-11-15 | 2007-11-16 |  | 14d |  | Workspace Coordinators | 8h |
| 295 | 1.3.5.2.17.21.6 | Configure search scopes | 1d? | 2007-11-15 | 2007-11-16 |  | 14d |  | Workspace Coordinators | 8h |
| 296 | 1.3.5.2.17.21.7 | Establish and implement search monitoring and tuning plan | 1d? | 2007-11-15 | 2007-11-16 |  | 14d |  | Workspace Coordinators | 8h |
| 297 | 1.3.5.2.17.21.8 | Document as needed | 1d? | 2007-11-15 | 2007-11-16 |  | 14d |  | Workspace Coordinators | 8h |

| ID | WBS | Task | Duration | Start | Finish | Predecessors | Total slack | Resources | Work |
| --- | --- | --- | --- | --- | --- | --- | --- | --- | --- |
| 298 | 1.3.5.2.17.22 | **Configure Document Management** | 15d | 2007-11-15 | 2007-12-06 |  | 0d |  | 208h |
| 299 | 1.3.5.2.17.22.1 | **Create Folder Structure** | 6d | 2007-11-15 | 2007-11-23 |  | 0d |  | 72h |
| 300 | 1.3.5.2.17.22.1.1 | Assign roles for security | 3d | 2007-11-15 | 2007-11-20 |  | 0d | Workspace Coordinators | 24h |
| 301 | 1.3.5.2.17.22.1.2 | Choose publishing process | 3d | 2007-11-20 | 2007-11-23 | 300 | 9d | Workspace Coordinators | 24h |
| 302 | 1.3.5.2.17.22.1.3 | Add approval routing | 3d | 2007-11-20 | 2007-11-23 | 300 | 0d | Workspace Coordinators | 24h |
| 303 | 1.3.5.2.17.22.2 | **Create Document Profiles and Custom Profiles** | 2d | 2007-11-23 | 2007-11-27 |  | 0d |  | 24h |
| 304 | 1.3.5.2.17.22.2.1 | Plan document profiles | 1d | 2007-11-23 | 2007-11-26 | 302 | 8d | Workspace Coordinators | 8h |
| 305 | 1.3.5.2.17.22.2.2 | Emphasize subjects with keywords | 1d | 2007-11-23 | 2007-11-26 | 302 | 0d | Workspace Coordinators | 8h |
| 306 | 1.3.5.2.17.22.2.3 | Enable Web discussions | 1d | 2007-11-26 | 2007-11-27 | 305 | 0d | Workspace Coordinators | 8h |
| 307 | 1.3.5.2.17.22.3 | **Move Documents into the Workspace** | 7d | 2007-11-27 | 2007-12-06 |  | 0d |  | 112h |
| 308 | 1.3.5.2.17.22.3.1 | Move multiple individual documents | 7d | 2007-11-27 | 2007-12-06 | 306 | 0d | Workspace Coordinators | 56h |
| 309 | 1.3.5.2.17.22.3.2 | Import existing folders | 7d | 2007-11-27 | 2007-12-06 | 306 | 0d | Workspace Coordinators | 56h |
| 310 | 1.3.5.2.17.23 | Configure alerts | 2d | 2007-11-15 | 2007-11-19 |  | 13d | Workspace Coordinators | 16h |
| 311 | 1.3.5.2.17.24 | Configure personal sites | 5d | 2007-11-15 | 2007-11-22 |  | 10d | Workspace Coordinators | 40h |
| 312 | 1.3.5.2.17.25 | Review single sign-on service requirements, consider Kerberos | 5d | 2007-11-15 | 2007-11-22 |  | 10d | MOSS 2007 Administrator; Workspace Coordinators | 80h |
| 313 | 1.3.5.2.17.26 | Configure Microsoft Office SharePoint Server 2007 for extranet use as desired | 2d | 2007-11-15 | 2007-11-19 |  | 13d | Intranet/Internet Administrator | 16h |
| 314 | 1.3.5.3 | Implement solutions and applicable third party solutions if any | 5d | 2007-12-06 | 2007-12-13 | 251 | 0d | Intranet/Internet Administrator | 40h |
| 315 | 1.3.5.4 | Implement interop and BDC integration | 5d | 2007-12-06 | 2007-12-13 | 251 | 0d | Intranet/Internet Administrator | 40h |
| 316 | 1.3.5.5 | Document as needed | 1d? | 2007-10-25 | 2007-10-26 |  | 34d | Intranet/Internet Administrator | 8h |
| 317 | 1.3.5.6 | **Deploy updates to Client Machines as needed** | 5d? | 2007-10-25 | 2007-11-01 |  | 30d |  | 128h |
| 318 | 1.3.5.6.1 | Update client operating systems as needed | 5d | 2007-10-25 | 2007-11-01 |  | 30d | Desktop Administrator | 40h |
| 319 | 1.3.5.6.2 | Update client browsers as needed | 5d | 2007-10-25 | 2007-11-01 |  | 30d | Desktop Administrator | 40h |
| 320 | 1.3.5.6.3 | Update client software as needed | 5d | 2007-10-25 | 2007-11-01 |  | 30d | Desktop Administrator | 40h |
| 321 | 1.3.5.6.4 | Document as needed | 1d? | 2007-10-25 | 2007-10-26 |  | 34d | Desktop Administrator | 8h |

| ID | WBS | Task | Duration | Start | Finish | Total slack | Free slack | Resources | Work |
| --- | --- | --- | --- | --- | --- | --- | --- | --- | --- |
| 322 | 1.3.5.7 | **Test and Evaluate System** | 5d? | 2007-10-25 | 2007-11-01 | 30d | 0d |  | 296h |
| 323 | 1.3.5.7.1 | **Test MOSS 2007** | 5d? | 2007-10-25 | 2007-11-01 | 30d |  |  | 296h |
| 324 | 1.3.5.7.1.1 | Test based on usage patterns and business scenarios | 1d? | 2007-10-25 | 2007-10-26 | 34d |  | Test/QA Lead | 8h |
| 325 | 1.3.5.7.1.2 | Test search and indexing | 5d | 2007-10-25 | 2007-11-01 | 30d |  | Test/QA Lead | 40h |
| 326 | 1.3.5.7.1.3 | Test solutions | 5d | 2007-10-25 | 2007-11-01 | 30d |  | Test/QA Lead | 40h |
| 327 | 1.3.5.7.1.4 | Test integrations | 5d | 2007-10-25 | 2007-11-01 | 30d |  | Test/QA Lead | 40h |
| 328 | 1.3.5.7.1.5 | Test Security and Hardening - evaluate for intrusion detection as needed | 1d? | 2007-10-25 | 2007-10-26 | 34d |  |  |  |
| 329 | 1.3.5.7.1.6 | Document as needed | 1d? | 2007-10-25 | 2007-10-26 | 34d |  | Test/QA Lead | 8h |
| 330 | 1.3.5.7.1.7 | **Training** | 1d? | 2007-10-25 | 2007-10-26 | 34d |  |  | 160h |
| 331 | 1.3.5.7.1.7.1 | **System Administrator Training** | 1d? | 2007-10-25 | 2007-10-26 | 34d |  |  | 32h |
| 332 | 1.3.5.7.1.7.1.1 | Identify Attendees | 1d? | 2007-10-25 | 2007-10-26 | 34d |  | Education/Training Lead | 8h |
| 333 | 1.3.5.7.1.7.1.2 | Schedule System Admin Training | 1d? | 2007-10-25 | 2007-10-26 | 34d |  | Education/Training Lead | 8h |
| 334 | 1.3.5.7.1.7.1.3 | Build System Admin Training | 1d? | 2007-10-25 | 2007-10-26 | 34d |  | Education/Training Lead | 8h |
| 335 | 1.3.5.7.1.7.1.4 | Conduct System Administration Training | 1d? | 2007-10-25 | 2007-10-26 | 34d |  | Education/Training Lead | 8h |
| 336 | 1.3.5.7.1.7.2 | Accept System Administration Training Materials | 1d? | 2007-10-25 | 2007-10-26 | 34d |  | Education/Training Lead | 8h |
| 337 | 1.3.5.7.1.7.3 | **Developer Training** | 1d? | 2007-10-25 | 2007-10-26 | 34d |  |  | 32h |
| 338 | 1.3.5.7.1.7.3.1 | Identify Attendees | 1d? | 2007-10-25 | 2007-10-26 | 34d |  | Education/Training Lead | 8h |
| 339 | 1.3.5.7.1.7.3.2 | Schedule Developer Training | 1d? | 2007-10-25 | 2007-10-26 | 34d |  | Education/Training Lead | 8h |
| 340 | 1.3.5.7.1.7.3.3 | Build Developer Training | 1d? | 2007-10-25 | 2007-10-26 | 34d |  | Education/Training Lead | 8h |
| 341 | 1.3.5.7.1.7.3.4 | Conduct Developer Training | 1d? | 2007-10-25 | 2007-10-26 | 34d |  | Education/Training Lead | 8h |
| 342 | 1.3.5.7.1.7.4 | Accept Developer Training Materials | 1d? | 2007-10-25 | 2007-10-26 | 34d |  | Education/Training Lead | 8h |
| 343 | 1.3.5.7.1.7.5 | **Train End Users** | 1d? | 2007-10-25 | 2007-10-26 | 34d |  |  | 32h |
| 344 | 1.3.5.7.1.7.5.1 | Identify Attendees | 1d? | 2007-10-25 | 2007-10-26 | 34d |  | Education/Training Lead | 8h |
| 345 | 1.3.5.7.1.7.5.2 | Schedule End User Training | 1d? | 2007-10-25 | 2007-10-26 | 34d |  | Education/Training Lead | 8h |
| 346 | 1.3.5.7.1.7.5.3 | Build End User Training | 1d? | 2007-10-25 | 2007-10-26 | 34d |  | Education/Training Lead | 8h |
| 347 | 1.3.5.7.1.7.5.4 | Conduct End User Training | 1d? | 2007-10-25 | 2007-10-26 | 34d |  | Education/Training Lead | 8h |
| 348 | 1.3.5.7.1.7.6 | Accept End User Training Materials | 1d? | 2007-10-25 | 2007-10-26 | 34d |  | Education/Training Lead | 8h |

| ID | WBS | Task | Type | Duration | Start | Finish | Predecessors | Total slack | Free slack | Resources | Work |
| --- | --- | --- | --- | --- | --- | --- | --- | --- | --- | --- | --- |
| 349 | 1.3.5.7.1.7.7 | **Support Training** |  | 1d? | 2007-10-25 | 2007-10-26 |  | 34d |  |  | 32h |
| 350 | 1.3.5.7.1.7.7.1 | Identify Attendees |  | 1d? | 2007-10-25 | 2007-10-26 |  | 34d |  | Education/Training Lead | 8h |
| 351 | 1.3.5.7.1.7.7.2 | Schedule Support Training |  | 1d? | 2007-10-25 | 2007-10-26 |  | 34d |  | Education/Training Lead | 8h |
| 352 | 1.3.5.7.1.7.7.3 | Build Support Training |  | 1d? | 2007-10-25 | 2007-10-26 |  | 34d |  | Education/Training Lead | 8h |
| 353 | 1.3.5.7.1.7.7.4 | Conduct Support Training |  | 1d? | 2007-10-25 | 2007-10-26 |  | 34d |  | Education/Training Lead | 8h |
| 354 | 1.3.5.7.1.7.8 | Accept Support Training Materials |  | 1d? | 2007-10-25 | 2007-10-26 |  | 34d |  | Education/Training Lead | 8h |
| 355 | 1.3.5.7.1.7.9 | Generate plan for updating and supporting continued training |  | 1d? | 2007-10-25 | 2007-10-26 |  | 34d |  |  |  |
| 356 | 1.3.5.8 | Production deployment complete | milestone | 0d | 2007-11-01 | 2007-11-01 | 322 | 30d | 0d |  |  |
| 357 | 1.3.6 | Deploy production system complete | milestone | 0d | 2007-11-01 | 2007-11-01 | 356 | 30d |  |  |  |
| 358 | 1.4 | **Post-Implementation Operations, Optimization and Business Review** |  | 32d? | 2007-12-13 | 2008-01-28 | 230 | 0d |  |  | 2960h |
| 359 | 1.4.1 | **Maintain System** |  | 30d? | 2007-12-13 | 2008-01-24 |  | 0d |  |  | 2912h |
| 360 | 1.4.1.1 | **Backup and Restore/Disaster Recovery & Business Continuance** |  | 2d? | 2007-12-13 | 2007-12-17 |  | 28d |  |  | 32h |
| 361 | 1.4.1.1.1 | Perform backups |  | 1d | 2007-12-13 | 2007-12-14 |  | 28d | 0d | MOSS 2007 Administrator; Database Administrator | 16h |
| 362 | 1.4.1.1.2 | Test restore/disaster recovery |  | 1d | 2007-12-14 | 2007-12-17 | 361 | 28d |  | MOSS 2007 Administrator; Database Administrator | 16h |
| 363 | 1.4.1.1.3 | Document as needed |  | 1d? | 2007-12-13 | 2007-12-14 |  | 29d |  |  |  |
| 364 | 1.4.1.2 | **Reporting and Monitor Growth and Performance** |  | 30d? | 2007-12-13 | 2008-01-24 |  | 0d |  |  | 2400h |
| 365 | 1.4.1.2.1 | Monitor SQL Server performance |  | 30d | 2007-12-13 | 2008-01-24 |  | 0d |  | MOSS 2007 Administrator; Database Administrator | 480h |
| 366 | 1.4.1.2.2 | Monitor Web front end performance |  | 30d | 2007-12-13 | 2008-01-24 |  | 0d |  | Intranet/Internet Administrator | 240h |
| 367 | 1.4.1.2.3 | Monitor search performance |  | 30d | 2007-12-13 | 2008-01-24 |  | 0d |  | Intranet/Internet Administrator | 240h |
| 368 | 1.4.1.2.4 | Re-forecast system requirements and capacity |  | 30d | 2007-12-13 | 2008-01-24 |  | 0d |  | MOSS 2007 Administrator; Intranet/Internet Administrator; Database Administrator | 720h |
| 369 | 1.4.1.2.5 | Plan for additional capacity as needed |  | 30d | 2007-12-13 | 2008-01-24 |  | 0d |  | MOSS 2007 Administrator; Intranet/Internet Administrator; Database Administrator | 720h |
| 370 | 1.4.1.2.6 | Weekly performance review (storage, performance, growth, trends, etc.) |  | 1d? | 2007-12-13 | 2007-12-14 |  | 29d |  |  |  |
| 371 | 1.4.1.3 | Resolve client/connectivity issues |  | 30d | 2007-12-13 | 2008-01-24 |  | 0d |  | MOSS 2007 Administrator; Desktop Administrator | 480h |
| 372 | 1.4.2 | Maintain web parts library |  | 1d? | 2007-12-13 | 2007-12-14 |  | 31d |  | MOSS 2007 Administrator; Desktop Administrator | 16h |
| 373 | 1.4.3 | Continuous documentation of user feedback |  | 1d | 2008-01-24 | 2008-01-25 | 359 | 0d |  | Project Manager; End Users | 16h |
| 374 | 1.4.4 | UI and structure updates as necessary |  | 1d | 2008-01-25 | 2008-01-28 | 373 | 0d |  | Project Manager; End Users | 16h |
| 375 | 1.4.5 | Post-implementation review complete | milestone | 0d | 2008-01-28 | 2008-01-28 | 374 | 0d |  | MOSS 2007 Administrator |  |
| 376 | 1.5 | Deployment complete |  | 1d? | 2007-08-01 | 2007-08-01 |  | 127.75d |  |  |  |
| 377 | 1.6 | Weekly operations meeting |  | 1d? | 2007-08-01 | 2007-08-01 |  | 127.75d |  | Project Manager | 8h |
| 378 | 1.7 | Monthly business review |  | 1d? | 2007-08-01 | 2007-08-01 |  | 127.75d |  | Project Manager | 8h |
| 379 | 1.8 | Monthly technical / infrastructure review |  | 1d? | 2007-08-01 | 2007-08-01 |  | 127.75d |  | Project Manager | 8h |
| 380 | 1.9 | Continue recuring business and technical reviews as necessary |  | 1d? | 2007-08-01 | 2007-08-01 |  | 127.75d |  | Project Manager | 8h |
| 381 | 1.10 | Review environment for migrations, departmental solutions, service packs and hotfixes updates as needed |  | 1d? | 2007-08-01 | 2007-08-01 |  | 127.75d |  | Project Manager | 8h |
